# Proyecto ladrillera

Schedule from MS Project, 2013-03-11 to 2013-05-03, costs in $, A marks actual dates.

## Calendars

- Estándar: Mon-Fri 09:00-13:00, 15:00-19:00; Sat-Sun off. Exceptions (off unless hours are given): 2013-03-25 (Festivo), 2013-03-28 (Jueves santo), 2013-03-29 (Viernes santo).

## Resources

| Resource | Unit | Rate |
| --- | --- | --- |
| Ingeniero Master |  | 15000 |
| Ingeniero Junior 1 |  | 12000 |
| Ingeniero Junior 2 |  | 10000 |
| Ingeniero Junior 3 |  | 10000 |
| Papel | resma | 8000 |
| cena |  |  |
| Transporte |  |  |
| Decámetro | unidad | 10000 |
| Video beam | unidad |  |

## Schedule

| ID | WBS | Task | Type | Duration | Start | Finish | Predecessors | Complete | Actual start | Baseline start | Baseline finish | Baseline duration | Constraint | Resources | Work | Actual work | Cost | Baseline cost | Actual cost |
| --- | --- | --- | --- | --- | --- | --- | --- | --- | --- | --- | --- | --- | --- | --- | --- | --- | --- | --- | --- |
| 1 | 1 | **Problemática** |  | 5d | 2013-03-11 A | 2013-03-15 A |  | 100% |  | 2013-03-11 | 2013-03-13 | 3d |  |  | 40h | 40h | 480,000 | 480,000 | 480,000 |
| 2 | 1.1 | Definir el problema |  | 2d | 2013-03-11 A | 2013-03-12 A |  | 100% |  | 2013-03-11 | 2013-03-12 | 2d |  | Ingeniero Junior 3; Ingeniero Junior 1; Ingeniero Master; Decámetro [1 unidad]; Ingeniero Junior 2; cena [0.1%]; Transporte [0.1%] | 16h | 16h | 198,000 | 198,000 | 198,000 |
| 3 | 1.2 | Definir posibles soluciones |  | 3d | 2013-03-13 A | 2013-03-15 A | 2 | 100% |  | 2013-03-11 | 2013-03-13 | 3d |  | Ingeniero Junior 3; Ingeniero Junior 1 [50%]; Ingeniero Master [33.3%]; Ingeniero Junior 2; cena [0.1%] | 24h | 24h | 282,000 | 282,000 | 282,000 |
| 4 | 1.10 | Fin de fase 1 | milestone | 0d | 2013-03-15 A | 2013-03-15 A | 3 | 100% |  | 2013-03-13 | 2013-03-13 | 0d | finish no earlier than 2013-03-15 |  |  |  |  |  |  |
| 5 | 2 | **Dimensionamiento de bodega de producto terminado** |  | 18d | 2013-03-18 A | 2013-04-15 A | 1 | 100% |  | 2013-03-14 | 2013-04-08 | 15d |  |  | 264h | 264h | 3,200,000 | 3,200,000 | 3,200,000 |
| 6 | 2.16 | Revisión de métodos |  | 3d | 2013-03-18 A | 2013-03-20 A |  | 100% |  | 2013-03-14 | 2013-03-18 | 3d |  | Ingeniero Master | 24h | 24h | 360,000 | 360,000 | 360,000 |
| 7 | 2.17 | Selección y ejecución de modelo |  | 10d | 2013-03-21 A | 2013-04-08 A | 6 | 100% |  | 2013-03-14 | 2013-04-01 | 10d |  | Ingeniero Junior 1 | 80h | 80h | 960,000 | 960,000 | 960,000 |
| 8 | 2.18 | Resultados del modelo |  | 2d | 2013-04-09 A | 2013-04-10 A | 7 | 100% |  | 2013-04-02 | 2013-04-03 | 2d |  | Ingeniero Junior 2; Ingeniero Junior 3; Ingeniero Junior 1; Ingeniero Master | 64h | 64h | 752,000 | 752,000 | 752,000 |
| 9 | 2.19 | Análisis de indicadores |  | 3d | 2013-04-11 A | 2013-04-15 A | 8 | 100% |  | 2013-04-04 | 2013-04-08 | 3d |  | Ingeniero Junior 2; Ingeniero Junior 3; Ingeniero Junior 1; Ingeniero Master | 96h | 96h | 1,128,000 | 1,128,000 | 1,128,000 |
| 10 | 2.20 | Fin de fase 2 | milestone | 0d | 2013-04-15 A | 2013-04-15 A | 9 | 100% |  | 2013-04-08 | 2013-04-08 | 0d | finish no earlier than 2013-04-15 |  |  |  |  |  |  |
| 11 | 3 | **Configuración interna de la bodega** |  | 3d | 2013-04-16 A | 2013-04-18 A | 5 | 100% |  | 2013-04-09 | 2013-04-11 | 3d |  |  |  |  |  | 360,000 |  |
| 12 | 3.6 | Configuración interna de la bodega |  | 3d | 2013-04-16 A | 2013-04-18 A |  | 100% |  |  |  |  |  |  |  |  |  |  |  |
| 13 | 3.5 | Fin de fase 3 | milestone | 0d | 2013-04-18 A | 2013-04-18 A | 12 | 100% |  | 2013-04-11 | 2013-04-11 | 0d |  |  |  |  |  |  |  |
| 14 | 4 | **Localizacilos productos dentro de la bodega** |  | 4d | 2013-04-19 A | 2013-04-24 A | 11 | 100% |  | 2013-04-12 | 2013-04-17 | 4d |  |  | 32h | 32h | 320,000 | 320,000 | 320,000 |
| 15 | 4.8 | Determinación del COI |  | 2d | 2013-04-19 A | 2013-04-22 A |  | 100% |  | 2013-04-12 | 2013-04-15 | 2d |  | Ingeniero Junior 3 | 16h | 16h | 160,000 | 160,000 | 160,000 |
| 16 | 4.9 | Clasificación para picking |  | 2d | 2013-04-23 A | 2013-04-24 A | 15 | 100% |  | 2013-04-16 | 2013-04-17 | 2d |  | Ingeniero Junior 2 | 16h | 16h | 160,000 | 160,000 | 160,000 |
| 17 | 4.10 | Fin de fase 4 | milestone | 0d | 2013-04-24 A | 2013-04-24 A | 16 | 100% |  | 2013-04-17 | 2013-04-17 | 0d |  |  |  |  |  |  |  |
| 18 | 5 | **Entrega y presentación** |  | 7d | 2013-04-25 | 2013-05-03 A | 14 | 100% | 2013-05-02 | 2013-04-18 | 2013-04-25 | 5.38d |  |  | 31h | 31h | 325,000 | 325,000 | 325,000 |
| 19 | 5.8 | Diseño de presentación |  | 1d | 2013-05-02 A | 2013-05-02 A |  | 100% |  | 2013-04-18 | 2013-04-18 | 1d | start no earlier than 2013-05-02 | Ingeniero Junior 3; Ingeniero Junior 1; Papel [1 resma] | 16h | 16h | 184,000 | 184,000 | 184,000 |
| 20 | 5.9 | Entrega y presentación |  | 3h | 2013-05-03 A | 2013-05-03 A | 19 | 100% |  | 2013-04-25 | 2013-04-25 | 3h |  | Ingeniero Junior 2; Ingeniero Junior 3; Ingeniero Junior 1; Ingeniero Master; Transporte [0.1%]; Video beam [1 unidad] | 15h | 15h | 141,000 | 141,000 | 141,000 |
| 21 | 5.10 | Fin de fase 5 | milestone | 0d | 2013-05-03 A | 2013-05-03 A | 20 | 100% |  | 2013-04-25 | 2013-04-25 | 0d | finish no earlier than 2013-04-23 |  |  |  |  |  |  |
