# Proyecto ladrillera

Schedule from MS Project, 2013-03-11 to 2013-04-25, costs in $, A marks actual dates.

## Calendars

- Estándar: Mon-Fri 09:00-13:00, 15:00-19:00; Sat-Sun off. Exceptions (off unless hours are given): 2013-03-25 (Festivo), 2013-03-28 (Jueves santo), 2013-03-29 (Viernes santo).

## Resources

| Resource | Unit | Rate |
| --- | --- | --- |
| Mauricio Perea |  | 15000 |
| Julián Riascos |  | 12000 |
| David Jiménez |  | 10000 |
| Enrique Sanín |  | 10000 |
| Papel | resma | 8000 |
| cena |  |  |
| Transporte |  |  |
| Decámetro | unidad | 10000 |
| Video beam | unidad | 20000 |

## Schedule

| ID | WBS | Task | Type | Duration | Start | Finish | Predecessors | Complete | Remaining | Baseline start | Baseline finish | Baseline duration | Total slack | Free slack | Constraint | Resources | Work | Actual work | Cost | Baseline cost | Actual cost |
| --- | --- | --- | --- | --- | --- | --- | --- | --- | --- | --- | --- | --- | --- | --- | --- | --- | --- | --- | --- | --- | --- |
| 1 | 0 | Propuesta dimensionamiento de bodega de ladrillera |  | 30.75d | 2013-03-11 A | 2013-04-25 | 22FF | 1% | 30.34d | 2013-03-11 | 2013-04-25 | 30.38d | 0d |  | finish no earlier than 2013-04-25 |  |  |  |  | 4,685,000 |  |
| 2 | 1 | **Problemática** |  | 3d | 2013-03-11 A | 2013-03-13 A |  | 100% |  | 2013-03-11 | 2013-03-13 | 3d |  |  |  |  | 40h | 40h | 480,000 | 480,000 | 480,000 |
| 3 | 1.1 | Definir el problema |  | 2d | 2013-03-11 A | 2013-03-12 A |  | 100% |  | 2013-03-11 | 2013-03-12 | 2d |  |  |  | Enrique Sanín; Julián Riascos; Mauricio Perea; Decámetro [1 unidad]; David Jiménez; cena [0.1%]; Transporte [0.1%] | 16h | 16h | 198,000 | 198,000 | 198,000 |
| 4 | 1.2 | Definir posibles soluciones |  | 3d | 2013-03-11 A | 2013-03-13 A | 3SS | 100% |  | 2013-03-11 | 2013-03-13 | 3d |  |  |  | Enrique Sanín; Julián Riascos [50%]; Mauricio Perea [33.3%]; David Jiménez; cena [0.1%] | 24h | 24h | 282,000 | 282,000 | 282,000 |
| 5 | 1.3 | Fin de fase 1 | milestone | 0d | 2013-03-13 | 2013-03-13 | 2 |  |  | 2013-03-13 | 2013-03-13 | 0d | 27.75d |  | finish no earlier than 2013-03-10 |  |  |  |  |  |  |
| 6 | 2 | **Dimensionamiento de bodega de producto terminado** |  | 15d | 2013-03-14 A | 2013-04-08 | 2 | 44% | 8.33d | 2013-03-14 | 2013-04-08 | 15d | 0.38d | 0d |  |  | 264h | 64h | 3,200,000 | 3,200,000 | 840,000 |
| 7 | 2.1 | Revisión de métodos |  | 3d | 2013-03-14 A | 2013-03-18 A |  | 100% |  | 2013-03-14 | 2013-03-18 | 3d |  |  |  | Mauricio Perea | 24h | 24h | 360,000 | 360,000 | 360,000 |
| 8 | 2.2 | Selección y ejecución de modelo |  | 10d | 2013-03-14 A | 2013-04-01 | 7SS | 50% | 5d | 2013-03-14 | 2013-04-01 | 10d | 0.38d | 0d |  | Julián Riascos | 80h | 40h | 960,000 | 960,000 | 480,000 |
| 9 | 2.3 | Resultados del modelo |  | 2d | 2013-04-02 | 2013-04-03 | 8 |  |  | 2013-04-02 | 2013-04-03 | 2d | 0.38d | 0d |  | David Jiménez; Enrique Sanín; Julián Riascos; Mauricio Perea | 64h |  | 752,000 | 752,000 |  |
| 10 | 2.4 | Análisis de indicadores |  | 3d | 2013-04-04 | 2013-04-08 | 9 |  |  | 2013-04-04 | 2013-04-08 | 3d | 0.38d |  |  | David Jiménez; Enrique Sanín; Julián Riascos; Mauricio Perea | 96h |  | 1,128,000 | 1,128,000 |  |
| 11 | 2.5 | Fin de fase 2 | milestone | 0d | 2013-04-08 | 2013-04-08 | 6 |  |  | 2013-04-08 | 2013-04-08 | 0d | 12.75d |  |  |  |  |  |  |  |  |
| 12 | 3 | **Configuración interna de la bodega** |  | 3d | 2013-04-09 | 2013-04-11 | 6 |  |  | 2013-04-09 | 2013-04-11 | 3d | 0.38d | 0d |  |  | 24h |  | 360,000 | 360,000 |  |
| 13 | 3.1 | Modelo de configuración interna de la bodega |  | 3d | 2013-04-09 | 2013-04-11 |  |  |  | 2013-04-09 | 2013-04-11 | 3d | 0.38d |  |  | Mauricio Perea | 24h |  | 360,000 | 360,000 |  |
| 14 | 3.2 | Fin de fase 3 | milestone | 0d | 2013-04-11 | 2013-04-11 | 12 |  |  | 2013-04-11 | 2013-04-11 | 0d | 9.75d |  |  |  |  |  |  |  |  |
| 15 | 4 | **Localizacilos productos dentro de la bodega** |  | 4d | 2013-04-12 | 2013-04-17 | 12 |  |  | 2013-04-12 | 2013-04-17 | 4d | 0.38d | 0d |  |  | 32h |  | 320,000 | 320,000 |  |
| 16 | 4.1 | Determinación del COI |  | 2d | 2013-04-12 | 2013-04-15 |  |  |  | 2013-04-12 | 2013-04-15 | 2d | 0.38d | 0d |  | Enrique Sanín | 16h |  | 160,000 | 160,000 |  |
| 17 | 4.2 | Clasificación para picking |  | 2d | 2013-04-16 | 2013-04-17 | 16 |  |  | 2013-04-16 | 2013-04-17 | 2d | 0.38d | 0d |  | David Jiménez | 16h |  | 160,000 | 160,000 |  |
| 18 | 4.3 | Fin de fase 4 | milestone | 0d | 2013-04-17 | 2013-04-17 | 15 |  |  | 2013-04-17 | 2013-04-17 | 0d | 5.75d |  |  |  |  |  |  |  |  |
| 19 | 5 | **Entrega y presentación** |  | 5.38d | 2013-04-18 | 2013-04-25 |  |  |  | 2013-04-18 | 2013-04-25 | 5.38d | 0.38d |  |  |  | 31h |  | 385,000 | 325,000 |  |
| 20 | 5.1 | Diseño de presentación |  | 1d | 2013-04-18 | 2013-04-18 | 17 |  |  | 2013-04-18 | 2013-04-18 | 1d | 4.75d |  |  | Enrique Sanín; Julián Riascos; Papel [1 resma] | 16h |  | 184,000 | 184,000 |  |
| 21 | 5.2 | Entrega y presentación |  | 3h | 2013-04-25 | 2013-04-25 | 17FS+5d |  |  | 2013-04-25 | 2013-04-25 | 3h | 0.38d |  |  | David Jiménez; Enrique Sanín; Julián Riascos; Mauricio Perea; Transporte [0.1%]; Video beam [1 unidad] | 15h |  | 201,000 | 141,000 |  |
| 22 | 5.3 | Fin de fase 5 | milestone | 0d | 2013-04-25 | 2013-04-25 | 19 |  |  | 2013-04-25 | 2013-04-25 | 0d | 0d |  | finish no earlier than 2013-04-25 |  |  |  |  |  |  |
